# Cronograma Proyecto: Diseño, desarrollo e implementación de un sistema de información

Schedule from MS Project, 2024-04-10 to 2024-11-22, status date 2024-06-30, costs in $, A marks actual dates.

## Calendars

- Estándar: Mon-Fri 09:00-13:00, 15:00-19:00; Sat-Sun off.

## Resources

| Resource | Unit | Rate |
| --- | --- | --- |
| Ingeniero de desarrollo Frontend |  | 25000 |
| Ingeniero de desarrollo Backend |  | 25000 |
| Analista de requerimientos |  | 18000 |
| Analista QA |  | 18000 |
| Arquitecto de software |  | 30000 |
| Gerente de proyectos |  | 50000 |
| Ingeniero de infraestructura |  | 25000 |
| Profesional en gestión del cambio |  | 18000 |
| Coordinador de proyecto |  | 30000 |
| Computador admin | unidad | 2500000 |
| Servicio pasarelas de pago | licencia | 3200000 |
| Hosting | licencia | 900000 |
| Base de datos | licencia | 3200000 |
| Computador desallo | unidad | 4500000 |

## Schedule

| ID | WBS | Task | Duration | Start | Finish | Predecessors | Complete | Baseline start | Baseline finish | Baseline duration | Baseline 1 start | Baseline 1 finish | Constraint | Resources | Work | Actual work | Cost | Baseline cost | Actual cost | COSTO DE LINEA BASE | BAC |
| --- | --- | --- | --- | --- | --- | --- | --- | --- | --- | --- | --- | --- | --- | --- | --- | --- | --- | --- | --- | --- | --- |
| 1 | 1 | **Levantamiento de la información** | 8d | 2024-04-10 A | 2024-04-19 A |  | 100% | 2024-04-10 | 2024-04-19 | 8d | 2024-04-10 | 2024-04-19 |  |  | 32h | 32h | 2,100,000 | 2,100,000 | 2,100,000 |  |  |
| 2 | 1.1 | 1.1.1.1 Reuniones con el cliente para recopilar información | 8d | 2024-04-10 A | 2024-04-19 A |  | 100% | 2024-04-10 | 2024-04-19 | 8d | 2024-04-10 | 2024-04-19 |  | Gerente de proyectos [20%]; Computador admin [0.2 unidad] | 32h | 32h | 2,100,000 | 2,100,000 | 2,100,000 |  |  |
| 3 | 2 | **Documentación de análisis del requerimiento** | 7.33d | 2024-04-22 A | 2024-05-01 A |  | 100% | 2024-04-22 | 2024-05-01 | 7.33d | 2024-04-22 | 2024-05-01 |  |  | 36.8h | 36.8h | 3,874,200 | 3,874,200 | 3,874,200 |  |  |
| 4 | 2.1 | 1.1.2.1 Documentación requisitos funcionales y no funcionales | 4d | 2024-04-22 A | 2024-04-25 A | 2 | 100% | 2024-04-22 | 2024-04-25 | 4d | 2024-04-22 | 2024-04-25 |  | Analista de requerimientos [20%]; Computador admin [0.33 unidad] | 6.4h | 6.4h | 940,200 | 940,200 | 940,200 |  |  |
| 5 | 2.2 | 1.1.2.2 Definición del alcance | 3.2d | 2024-04-26 A | 2024-05-01 A | 4 | 100% | 2024-04-26 | 2024-05-01 | 3.2d | 2024-04-26 | 2024-05-01 |  | Arquitecto de software [25%]; Computador desallo [0.33 unidad] | 6.4h | 6.4h | 1,677,000 | 1,677,000 | 1,677,000 |  |  |
| 6 | 2.3 | 1.1.2.3 Realizar los casos de uso | 3.33d | 2024-04-26 A | 2024-05-01 A | 4 | 100% | 2024-04-26 | 2024-05-01 | 3.33d | 2024-04-26 | 2024-05-01 |  | Analista de requerimientos [90%]; Computador admin [0.33 unidad] | 24h | 24h | 1,257,000 | 1,257,000 | 1,257,000 |  |  |
| 7 | 3 | **Aprobación del requerimiento (Documento)** | 2d | 2024-05-01 A | 2024-05-03 A |  | 100% | 2024-05-01 | 2024-05-03 | 2d | 2024-05-01 | 2024-05-03 |  |  | 8h | 8h | 1,400,000 | 1,400,000 | 1,400,000 |  |  |
| 8 | 3.1 | 1.1.3.1 Reunión de revisión de la documentación con los stakeholders | 1d | 2024-05-01 A | 2024-05-02 A | 4, 5, 6 | 100% | 2024-05-01 | 2024-05-02 | 1d | 2024-05-01 | 2024-05-02 |  | Gerente de proyectos [50%]; Computador admin [0.2 unidad] | 4h | 4h | 700,000 | 700,000 | 700,000 |  |  |
| 9 | 3.2 | 1.1.3.2 Documentar formalmente la aprobación del documento | 1d | 2024-05-02 A | 2024-05-03 A | 8 | 100% | 2024-05-02 | 2024-05-03 | 1d | 2024-05-02 | 2024-05-03 |  | Gerente de proyectos [50%]; Computador admin [0.2 unidad] | 4h | 4h | 700,000 | 700,000 | 700,000 |  |  |
| 10 | 4 | **Definición de arquitectura** | 5d | 2024-05-03 A | 2024-05-10 A |  | 100% | 2024-05-03 | 2024-05-10 | 5d | 2024-05-03 | 2024-05-10 |  |  | 40h | 40h | 1,545,000 | 1,545,000 | 1,545,000 |  |  |
| 11 | 4.1 | 1.1.4.1 Realizar mockups | 5d | 2024-05-03 A | 2024-05-10 A | 9 | 100% | 2024-05-03 | 2024-05-10 | 5d | 2024-05-03 | 2024-05-10 |  | Analista de requerimientos; Computador admin [0.33 unidad] | 40h | 40h | 1,545,000 | 1,545,000 | 1,545,000 |  |  |
| 12 | 5 | **Diseño de estructura de datos** | 3d | 2024-05-03 A | 2024-05-08 A |  | 100% | 2024-05-03 | 2024-05-08 | 3d | 2024-05-03 | 2024-05-08 |  |  | 16.8h | 16.8h | 3,538,000 | 3,538,000 | 3,538,000 |  |  |
| 13 | 5.1 | 1.2.1.1 Realizar modelo de entidad relación | 2d | 2024-05-03 A | 2024-05-07 A | 9 | 100% | 2024-05-03 | 2024-05-07 | 2d | 2024-05-03 | 2024-05-07 | finish no earlier than 2024-05-06 | Arquitecto de software [70%]; Computador desallo [0.33 unidad]; Base de datos [0.01 licencia] | 11.2h | 11.2h | 1,853,000 | 1,853,000 | 1,853,000 |  |  |
| 14 | 5.2 | 1.2.1.2 Realizar diccionario de datos | 1d | 2024-05-07 A | 2024-05-08 A | 13 | 100% | 2024-05-07 | 2024-05-08 | 1d | 2024-05-07 | 2024-05-08 |  | Arquitecto de software [70%]; Computador desallo [0.33 unidad]; Base de datos [0.01 licencia] | 5.6h | 5.6h | 1,685,000 | 1,685,000 | 1,685,000 |  |  |
| 15 | 6 | **Diseño Funcional** | 8d | 2024-05-02 A | 2024-05-13 A |  | 100% | 2024-05-02 | 2024-05-13 | 8d | 2024-05-02 | 2024-05-13 |  |  | 32.89h | 32.89h | 1,836,666.67 | 1,836,666.67 | 1,836,666.67 |  |  |
| 16 | 6.1 | 1.2.2.1 Realizar análisis con el equipo técnico de los requisitos | 3.11d | 2024-05-02 A | 2024-05-09 A | 6 | 100% | 2024-05-02 | 2024-05-09 | 3.11d | 2024-05-02 | 2024-05-09 | start no earlier than 2024-05-02 | Coordinador de proyecto; Computador admin [0.17 unidad] | 24.89h | 24.89h | 1,171,666.67 | 1,171,666.67 | 1,171,666.67 | 247937,45 | 247937,45 |
| 17 | 6.2 | 1.2.2.2 Comunicar la estructura definida al equipo técnico | 1d | 2024-05-13 A | 2024-05-13 A | 16 | 100% | 2024-05-13 | 2024-05-13 | 1d | 2024-05-13 | 2024-05-13 | start no earlier than 2024-05-13 | Coordinador de proyecto; Computador admin [0.17 unidad] | 8h | 8h | 665,000 | 665,000 | 665,000 | -0 | -0 |
| 18 | 7 | **Diseño web** | 9.67d | 2024-05-03 A | 2024-05-16 A |  | 100% | 2024-05-03 | 2024-05-16 | 9.67d | 2024-05-03 | 2024-05-16 |  |  | 48h | 48h | 2,391,000 | 2,391,000 | 2,391,000 |  |  |
| 19 | 7.1 | 1.2.3.1 Realizar el modelo de desarrollo Ágil | 2d | 2024-05-15 A | 2024-05-16 A | 9, 11, 13 | 100% | 2024-05-15 | 2024-05-16 | 2d | 2024-05-15 | 2024-05-16 | start no earlier than 2024-05-15 | Coordinador de proyecto [50%]; Computador admin [0.17 unidad] | 8h | 8h | 665,000 | 665,000 | 665,000 |  |  |
| 20 | 7.2 | 1.2.3.3 Desarrollar el portal web para clientes | 5d | 2024-05-03 A | 2024-05-10 A | 9 | 100% | 2024-05-03 | 2024-05-10 | 5d | 2024-05-03 | 2024-05-10 | finish no earlier than 2024-05-10 | Ingeniero de desarrollo Frontend; Computador desallo [0.14 unidad]; Servicio pasarelas de pago [0.03 licencia]; Base de datos | 40h | 40h | 1,726,000 | 1,726,000 | 1,726,000 | 89858,44 | 89858,44 |
| 21 | 8 | **Diseño de interfaces de usuario** | 9.67d | 2024-05-10 A | 2024-05-23 A |  | 100% | 2024-05-10 | 2024-05-23 | 9.67d | 2024-05-10 | 2024-05-23 |  |  | 109.33h | 109.33h | 3,750,333.33 | 3,750,333.33 | 3,750,333.33 |  |  |
| 22 | 8.1 | 1.2.4.1 Realizar el diseño de las interfaces (Usabilidad ) | 5d | 2024-05-17 A | 2024-05-23 A | 11FS+1d | 100% | 2024-05-17 | 2024-05-23 | 5d | 2024-05-17 | 2024-05-23 | start no earlier than 2024-05-17 | Coordinador de proyecto; Computador admin [0.17 unidad]; Base de datos | 40h | 40h | 1,657,000 | 1,657,000 | 1,657,000 | 32000 | 32000 |
| 23 | 8.2 | 1.2.4.2 Desarrollar los módulos de usuarios | 8.67d | 2024-05-10 A | 2024-05-22 A | 9, 11 | 100% | 2024-05-10 | 2024-05-22 | 8.67d | 2024-05-10 | 2024-05-22 |  | Ingeniero de desarrollo Backend; Computador desallo [0.08 unidad]; Base de datos | 69.33h | 69.33h | 2,093,333.33 | 2,093,333.33 | 2,093,333.33 |  |  |
| 24 | 9 | **Control de permisos (roles)** | 21d | 2024-05-22 A | 2024-06-20 A |  | 100% | 2024-05-22 | 2024-06-20 | 21d | 2024-05-22 | 2024-06-20 |  |  | 126h | 126h | 5,110,000 | 5,110,000 | 5,110,000 |  |  |
| 25 | 9.1 | 1.3.1.1 Diseño catalogo de datos | 2d | 2024-05-23 A | 2024-05-28 A | 9, 11, 13, 14 | 100% | 2024-05-23 | 2024-05-28 | 2d | 2024-05-23 | 2024-05-28 | start no earlier than 2024-05-23 | Ingeniero de desarrollo Backend; Computador desallo [0.08 unidad]; Base de datos | 16h | 16h | 760,000 | 760,000 | 760,000 | 235862,07 | 235862,07 |
| 26 | 9.2 | 1.3.1.2 Desarrollo FE | 3d | 2024-05-22 A | 2024-05-30 A | 23 | 100% | 2024-05-22 | 2024-05-30 | 3d | 2024-05-22 | 2024-05-30 |  | Ingeniero de desarrollo Frontend; Computador desallo [0.14 unidad]; Servicio pasarelas de pago [0.03 licencia]; Base de datos | 24h | 24h | 1,358,000 | 1,358,000 | 1,358,000 | 543894,08 | 543894,08 |
| 27 | 9.3 | 1.3.1.3 Desarrollo de BE | 4d | 2024-05-29 A | 2024-06-07 A | 25 | 100% | 2024-05-29 | 2024-06-07 | 4d | 2024-05-29 | 2024-06-07 | start no earlier than 2024-05-29 | Ingeniero de desarrollo Backend; Computador desallo [0.08 unidad]; Servicio pasarelas de pago [0.03 licencia]; Base de datos | 32h | 32h | 1,288,000 | 1,288,000 | 1,288,000 | 317665,37 | 317665,37 |
| 28 | 9.4 | 1.3.1.4 Pruebas internas de desarrollo | 3d | 2024-06-10 A | 2024-06-12 A | 25, 26, 27 | 100% | 2024-06-10 | 2024-06-12 | 3d | 2024-06-10 | 2024-06-12 | start no earlier than 2024-06-10 | Analista QA; Computador desallo [0.06 unidad]; Servicio pasarelas de pago [0.03 licencia]; Base de datos | 24h | 24h | 798,000 | 798,000 | 798,000 |  |  |
| 29 | 9.5 | 1.3.1.5 Creación set de pruebas | 3.75d | 2024-06-13 A | 2024-06-20 A | 25, 26, 27 | 100% | 2024-06-13 | 2024-06-20 | 3.75d | 2024-06-13 | 2024-06-20 | start no earlier than 2024-06-13 | Analista QA; Computador desallo [0.06 unidad]; Servicio pasarelas de pago [0.03 licencia]; Base de datos | 30h | 30h | 906,000 | 906,000 | 906,000 | 161754,15 | 161754,15 |

| ID | WBS | Task | Duration | Start | Finish | Predecessors | Complete | Remaining | Baseline start | Baseline finish | Baseline duration | Baseline 1 start | Baseline 1 finish | Total slack | Free slack | Constraint | Resources | Work | Actual work | Cost | Baseline cost | Actual cost | COSTO DE LINEA BASE | BAC |
| --- | --- | --- | --- | --- | --- | --- | --- | --- | --- | --- | --- | --- | --- | --- | --- | --- | --- | --- | --- | --- | --- | --- | --- | --- |
| 30 | 10 | **Registro de clientes** | 25d | 2024-06-03 A | 2024-07-05 |  | 14% | 21.43d | 2024-06-03 | 2024-07-05 | 25d | 2024-06-03 | 2024-07-05 | 100d |  |  |  | 120h | 18h | 4,874,000 | 4,874,000 | 630,751.3 |  |  |
| 31 | 10.1 | 1.3.2.1 Diseño catalogo de datos | 2d | 2024-06-10 A | 2024-06-13 | 9, 11, 13, 14 | 25% | 1.5d | 2024-06-10 | 2024-06-13 | 2d | 2024-06-10 | 2024-06-13 | 116d |  | start no earlier than 2024-06-10 | Ingeniero de desarrollo Backend; Computador desallo [0.08 unidad] | 16h | 4h | 760,000 | 760,000 | 145,000 | 615000 | 615000 |
| 32 | 10.2 | 1.3.2.2 Desarrollo FE | 3d | 2024-06-03 A | 2024-06-10 | 23 | 25% | 2.25d | 2024-06-03 | 2024-06-10 | 3d | 2024-06-03 | 2024-06-10 | 119d |  | start no earlier than 2024-06-03 | Ingeniero de desarrollo Frontend; Computador desallo [0.14 unidad]; Servicio pasarelas de pago [0.03 licencia]; Base de datos | 24h | 6h | 1,326,000 | 1,326,000 | 240,751.3 | 1085248,7 | 1085248,7 |
| 33 | 10.3 | 1.3.2.3 Desarrollo de BE | 4d | 2024-06-14 A | 2024-06-25 | 25 | 25% | 3d | 2024-06-14 | 2024-06-25 | 4d | 2024-06-14 | 2024-06-25 | 108d |  | start no earlier than 2024-06-14 | Ingeniero de desarrollo Backend; Computador desallo [0.08 unidad]; Base de datos | 32h | 8h | 1,160,000 | 1,160,000 | 245,000 | 915000 | 915000 |
| 34 | 10.4 | 1.3.2.4 Pruebas internas de desarrollo | 3d | 2024-06-20 | 2024-06-27 | 25, 26, 27 |  |  | 2024-06-20 | 2024-06-27 | 3d | 2024-06-20 | 2024-06-27 | 90d | 52d | start no earlier than 2024-06-20 | Analista QA; Computador desallo [0.06 unidad]; Servicio pasarelas de pago [0.03 licencia]; Base de datos | 24h |  | 798,000 | 798,000 |  | 798000 | 798000 |
| 35 | 10.5 | 1.3.2.5 Creación set de pruebas | 3.75d | 2024-06-28 | 2024-07-05 | 25, 26, 27 |  |  | 2024-06-28 | 2024-07-05 | 3.75d | 2024-06-28 | 2024-07-05 | 67d | 46d | start no earlier than 2024-06-28 | Analista QA [80%]; Computador desallo [0.06 unidad]; Servicio pasarelas de pago [0.03 licencia]; Base de datos [0.01 licencia] | 24h |  | 830,000 | 830,000 |  | 830000 | 830000 |
| 36 | 11 | **Control de accesos** | 29d | 2024-06-11 | 2024-07-19 |  |  |  | 2024-06-11 | 2024-07-19 | 29d | 2024-06-11 | 2024-07-19 | 80d |  |  |  | 120h |  | 5,066,000 | 5,066,000 |  |  |  |
| 37 | 11.1 | 1.3.3.1 Diseño catalogo de datos | 2d | 2024-06-25 | 2024-06-28 | 9, 11, 13, 14 |  |  | 2024-06-25 | 2024-06-28 | 2d | 2024-06-25 | 2024-06-28 | 105d |  | start no earlier than 2024-06-25 | Ingeniero de desarrollo Backend; Computador desallo [0.08 unidad]; Base de datos [0.01 licencia] | 16h |  | 792,000 | 792,000 |  | 792000 | 792000 |
| 38 | 11.2 | 1.3.3.2 Desarrollo FE | 3d | 2024-06-11 | 2024-06-18 | 23 |  |  | 2024-06-11 | 2024-06-18 | 3d | 2024-06-11 | 2024-06-18 | 113d |  | start no earlier than 2024-06-11 | Ingeniero de desarrollo Frontend; Computador desallo [0.14 unidad]; Servicio pasarelas de pago [0.03 licencia]; Base de datos [0.01 licencia] | 24h |  | 1,358,000 | 1,358,000 |  | 1358000 | 1358000 |
| 39 | 11.3 | 1.3.3.3 Desarrollo de BE | 4d | 2024-06-28 | 2024-07-09 | 25 |  |  | 2024-06-28 | 2024-07-09 | 4d | 2024-06-28 | 2024-07-09 | 98d |  | start no earlier than 2024-06-28 | Ingeniero de desarrollo Backend; Computador desallo [0.08 unidad]; Servicio pasarelas de pago [0.03 licencia]; Base de datos [0.01 licencia] | 32h |  | 1,288,000 | 1,288,000 |  | 1288000 | 1288000 |
| 40 | 11.4 | 1.3.3.4 Pruebas internas de desarrollo | 3d | 2024-07-08 | 2024-07-11 | 25, 26, 27 |  |  | 2024-07-08 | 2024-07-11 | 3d | 2024-07-08 | 2024-07-11 | 80d | 42d | finish no earlier than 2024-07-11 | Analista QA; Computador desallo [0.06 unidad]; Servicio pasarelas de pago [0.03 licencia]; Base de datos | 24h |  | 798,000 | 798,000 |  | 798000 | 798000 |
| 41 | 11.5 | 1.3.3.5 Creación set de pruebas | 3d | 2024-07-12 | 2024-07-19 | 25, 26, 27 |  |  | 2024-07-12 | 2024-07-19 | 3d | 2024-07-12 | 2024-07-19 | 57d | 36d | start no earlier than 2024-07-12 | Analista QA; Computador desallo [0.06 unidad]; Servicio pasarelas de pago [0.03 licencia]; Base de datos [0.01 licencia] | 24h |  | 830,000 | 830,000 |  | 830000 | 830000 |
| 42 | 12 | **Gestión de pagos** | 34d | 2024-06-19 | 2024-08-05 |  |  |  | 2024-06-19 | 2024-08-05 | 34d | 2024-06-19 | 2024-08-05 | 74d |  |  |  | 104h |  | 4,762,000 | 4,762,000 |  |  |  |
| 43 | 12.1 | 1.3.4.1 Diseño catalogo de datos | 2d | 2024-07-10 | 2024-07-12 | 9, 11, 13, 14 |  |  | 2024-07-10 | 2024-07-12 | 2d | 2024-07-10 | 2024-07-12 | 95d |  | start no earlier than 2024-07-10 | Ingeniero de desarrollo Backend; Computador desallo [0.08 unidad]; Servicio pasarelas de pago [0.03 licencia]; Base de datos [0.01 licencia] | 16h |  | 888,000 | 888,000 |  | 888000 | 888000 |
| 44 | 12.2 | 1.3.4.2 Desarrollo FE | 3d | 2024-06-19 | 2024-06-26 | 23 |  |  | 2024-06-19 | 2024-06-26 | 3d | 2024-06-19 | 2024-06-26 | 107d |  | start no earlier than 2024-06-19 | Ingeniero de desarrollo Frontend; Computador desallo [0.14 unidad]; Servicio pasarelas de pago [0.03 licencia]; Base de datos [0.01 licencia] | 24h |  | 1,358,000 | 1,358,000 |  | 1358000 | 1358000 |
| 45 | 12.3 | 1.3.4.3 Desarrollo de BE | 2d | 2024-07-15 | 2024-07-16 | 25 |  |  | 2024-07-15 | 2024-07-16 | 2d | 2024-07-15 | 2024-07-16 | 93d |  | start no earlier than 2024-07-15 | Ingeniero de desarrollo Backend; Computador desallo [0.08 unidad]; Servicio pasarelas de pago [0.03 licencia]; Base de datos [0.01 licencia] | 16h |  | 888,000 | 888,000 |  | 888000 | 888000 |
| 46 | 12.4 | 1.3.4.4 Pruebas internas de desarrollo | 3d | 2024-07-22 | 2024-07-26 | 25, 26, 27 |  |  | 2024-07-22 | 2024-07-26 | 3d | 2024-07-22 | 2024-07-26 | 69d | 31d | finish no earlier than 2024-07-26 | Analista QA; Computador desallo [0.06 unidad]; Servicio pasarelas de pago [0.03 licencia]; Base de datos | 24h |  | 798,000 | 798,000 |  | 798000 | 798000 |
| 47 | 12.5 | 1.3.4.5 Creación set de pruebas | 3d | 2024-07-29 | 2024-08-05 | 25, 26, 27 |  |  | 2024-07-29 | 2024-08-05 | 3d | 2024-07-29 | 2024-08-05 | 46d | 25d | start no earlier than 2024-07-29 | Analista QA; Computador desallo [0.06 unidad]; Servicio pasarelas de pago [0.03 licencia]; Base de datos [0.01 licencia] | 24h |  | 830,000 | 830,000 |  | 830000 | 830000 |
| 48 | 13 | **Control de inventarios** | 40d | 2024-06-27 | 2024-08-21 |  |  |  | 2024-06-27 | 2024-08-21 | 40d | 2024-06-27 | 2024-08-21 | 67d |  |  |  | 120h |  | 5,098,000 | 5,098,000 |  |  |  |
| 49 | 13.1 | 1.3.5.1 Diseño catalogo de datos | 2d | 2024-07-17 | 2024-07-22 | 9, 11, 13, 14 |  |  | 2024-07-17 | 2024-07-22 | 2d | 2024-07-17 | 2024-07-22 | 89d |  | start no earlier than 2024-07-17 | Ingeniero de desarrollo Backend; Computador desallo [0.08 unidad]; Base de datos [0.01 licencia] | 16h |  | 792,000 | 792,000 |  | 792000 | 792000 |
| 50 | 13.2 | 1.3.5.2 Desarrollo FE | 3d | 2024-06-27 | 2024-07-04 | 23 |  |  | 2024-06-27 | 2024-07-04 | 3d | 2024-06-27 | 2024-07-04 | 101d |  | start no earlier than 2024-06-27 | Ingeniero de desarrollo Frontend; Computador desallo [0.14 unidad]; Servicio pasarelas de pago [0.03 licencia]; Base de datos [0.01 licencia] | 24h |  | 1,358,000 | 1,358,000 |  | 1358000 | 1358000 |
| 51 | 13.3 | 1.3.5.3 Desarrollo de BE | 4d | 2024-07-23 | 2024-08-01 | 25 |  |  | 2024-07-23 | 2024-08-01 | 4d | 2024-07-23 | 2024-08-01 | 81d |  | start no earlier than 2024-07-23 | Ingeniero de desarrollo Backend; Computador desallo [0.08 unidad]; Servicio pasarelas de pago [0.03 licencia]; Base de datos [0.01 licencia] | 32h |  | 1,288,000 | 1,288,000 |  | 1288000 | 1288000 |
| 52 | 13.4 | 1.3.5.4 Pruebas internas de desarrollo | 3d | 2024-08-06 | 2024-08-13 | 25, 26, 27 |  |  | 2024-08-06 | 2024-08-13 | 3d | 2024-08-06 | 2024-08-13 | 57d | 19d | start no earlier than 2024-08-06 | Analista QA; Computador desallo [0.06 unidad]; Servicio pasarelas de pago [0.03 licencia]; Base de datos [0.01 licencia] | 24h |  | 830,000 | 830,000 |  | 830000 | 830000 |
| 53 | 13.5 | 1.3.5.5 Creación set de pruebas | 3d | 2024-08-14 | 2024-08-21 | 25, 26, 27 |  |  | 2024-08-14 | 2024-08-21 | 3d | 2024-08-14 | 2024-08-21 | 34d | 13d | start no earlier than 2024-08-14 | Analista QA; Computador desallo [0.06 unidad]; Servicio pasarelas de pago [0.03 licencia]; Base de datos [0.01 licencia] | 24h |  | 830,000 | 830,000 |  | 830000 | 830000 |

| ID | WBS | Task | Duration | Start | Finish | Predecessors | Complete | Remaining | Baseline start | Baseline finish | Baseline duration | Baseline 1 start | Baseline 1 finish | Total slack | Free slack | Constraint | Resources | Work | Actual work | Cost | Baseline cost | Actual cost | COSTO DE LINEA BASE | BAC |
| --- | --- | --- | --- | --- | --- | --- | --- | --- | --- | --- | --- | --- | --- | --- | --- | --- | --- | --- | --- | --- | --- | --- | --- | --- |
| 54 | 14 | **Reportes** | 47d | 2024-07-05 | 2024-09-09 |  |  |  | 2024-07-05 | 2024-09-09 | 47d | 2024-07-05 | 2024-09-09 | 54d |  |  |  | 120h |  | 5,098,000 | 5,098,000 |  |  |  |
| 55 | 14.1 | 1.3.6.1 Diseño catalogo de datos | 2d | 2024-08-02 | 2024-08-07 | 9, 11, 13, 14 |  |  | 2024-08-02 | 2024-08-07 | 2d | 2024-08-02 | 2024-08-07 | 77d |  | start no earlier than 2024-08-02 | Ingeniero de desarrollo Backend; Computador desallo [0.08 unidad]; Base de datos [0.01 licencia] | 16h |  | 792,000 | 792,000 |  | 792000 | 792000 |
| 56 | 14.2 | 1.3.6.2 Desarrollo FE | 3d | 2024-07-05 | 2024-07-12 | 23 |  |  | 2024-07-05 | 2024-07-12 | 3d | 2024-07-05 | 2024-07-12 | 95d |  | start no earlier than 2024-07-05 | Ingeniero de desarrollo Frontend; Computador desallo [0.14 unidad]; Servicio pasarelas de pago [0.03 licencia]; Base de datos [0.01 licencia] | 24h |  | 1,358,000 | 1,358,000 |  | 1358000 | 1358000 |
| 57 | 14.3 | 1.3.6.3 Desarrollo de BE | 4d | 2024-08-09 | 2024-08-20 | 25 |  |  | 2024-08-09 | 2024-08-20 | 4d | 2024-08-09 | 2024-08-20 | 68d |  | start no earlier than 2024-08-09 | Ingeniero de desarrollo Backend; Computador desallo [0.08 unidad]; Servicio pasarelas de pago [0.03 licencia]; Base de datos [0.01 licencia] | 32h |  | 1,288,000 | 1,288,000 |  | 1288000 | 1288000 |
| 58 | 14.4 | 1.3.6.4 Pruebas internas de desarrollo | 3d | 2024-08-22 | 2024-08-29 | 25, 26, 27 |  |  | 2024-08-22 | 2024-08-29 | 3d | 2024-08-22 | 2024-08-29 | 45d | 7d | start no earlier than 2024-08-22 | Analista QA; Computador desallo [0.06 unidad]; Servicio pasarelas de pago [0.03 licencia]; Base de datos [0.01 licencia] | 24h |  | 830,000 | 830,000 |  | 830000 | 830000 |
| 59 | 14.5 | 1.3.6.5 Creación set de pruebas | 3d | 2024-09-02 | 2024-09-09 | 25, 26, 27 |  |  | 2024-09-02 | 2024-09-09 | 3d | 2024-09-02 | 2024-09-09 | 21d | 0d | start no earlier than 2024-09-02 | Analista QA; Computador desallo [0.06 unidad]; Servicio pasarelas de pago [0.03 licencia]; Base de datos [0.01 licencia] | 24h |  | 830,000 | 830,000 |  | 830000 | 830000 |
| 60 | 15 | **Adecuación de los ambientes** | 26d | 2024-05-23 A | 2024-06-27 |  | 11% | 23.07d | 2024-05-23 | 2024-06-27 | 26d | 2024-05-23 | 2024-06-27 | 106d |  |  |  | 160h | 18h | 7,526,000 | 7,526,000 | 574,500 |  |  |
| 61 | 15.1 | 1.4.1.1 Equipos de computo | 5d | 2024-05-24 | 2024-05-30 |  |  |  | 2024-05-24 | 2024-05-30 | 5d | 2024-05-24 | 2024-05-30 | 1.25d | 0d | start no earlier than 2024-05-24 | Coordinador de proyecto; Computador admin [0.17 unidad]; Base de datos [0.01 licencia] | 40h |  | 1,657,000 | 1,657,000 |  | 1657000 | 1657000 |
| 62 | 15.2 | 1.4.1.2 Hosting | 5d | 2024-05-23 A | 2024-05-31 |  | 20% | 4d | 2024-05-23 | 2024-05-31 | 5d | 2024-05-23 | 2024-05-31 | 125d |  | finish no earlier than 2024-05-31 | Ingeniero de infraestructura; Computador desallo [0.2 unidad]; Base de datos [0.01 licencia]; Hosting [0.01 licencia] | 40h | 8h | 1,941,000 | 1,941,000 | 200,000 | 1741000 | 1741000 |
| 63 | 15.3 | 1.4.1.4 Adecuación de herramientas de desarrollo | 5d | 2024-05-30 | 2024-06-13 | 61 |  |  | 2024-05-30 | 2024-06-13 | 5d | 2024-05-30 | 2024-06-13 | 1.25d | 0d |  | Ingeniero de infraestructura; Computador desallo [0.2 unidad]; Base de datos [0.01 licencia] | 40h |  | 1,932,000 | 1,932,000 |  | 1932000 | 1932000 |
| 64 | 15.4 | 1.4.1.3 Pasera de pago | 5d | 2024-06-13 A | 2024-06-27 | 63 | 25% | 3.75d | 2024-06-13 | 2024-06-27 | 5d | 2024-06-13 | 2024-06-27 | 106d |  |  | Ingeniero de infraestructura; Computador desallo [0.2 unidad]; Servicio pasarelas de pago [0.03 licencia]; Base de datos | 40h | 10h | 1,996,000 | 1,996,000 | 374,500 | 1621500 | 1621500 |
| 65 | 16 | **Pruebas funcionales** | 16d | 2024-09-10 | 2024-10-01 |  |  |  | 2024-09-10 | 2024-10-01 | 16d | 2024-09-10 | 2024-10-01 | 38d |  |  |  | 72h |  | 2,092,000 | 2,092,000 |  |  |  |
| 66 | 16.1 | 1.4.2.1 Ejecución de pruebas por el equipo técnico | 3d | 2024-09-10 | 2024-09-13 | 28, 34, 40, 46, 52, 58 |  |  | 2024-09-10 | 2024-09-13 | 3d | 2024-09-10 | 2024-09-13 | 38d | 0d | finish no earlier than 2024-09-13 | Analista QA; Computador desallo [0.06 unidad]; Servicio pasarelas de pago [0.03 licencia]; Base de datos [0.01 licencia] | 24h |  | 830,000 | 830,000 |  | 830000 | 830000 |
| 67 | 16.2 | 1.4.2.2 Documentación de las pruebas y corrección de fallas | 6d | 2024-09-13 | 2024-10-01 | 66 |  |  | 2024-09-13 | 2024-10-01 | 6d | 2024-09-13 | 2024-10-01 | 38d |  |  | Analista QA; Computador desallo [0.06 unidad]; Servicio pasarelas de pago [0.03 licencia]; Base de datos [0.01 licencia] | 48h |  | 1,262,000 | 1,262,000 |  | 1262000 | 1262000 |
| 68 | 17 | **Pruebas de integración** | 15d | 2024-10-02 | 2024-10-22 |  |  |  | 2024-10-02 | 2024-10-22 | 15d | 2024-10-02 | 2024-10-22 | 23d |  |  |  | 88h |  | 2,778,000 | 2,778,000 |  |  |  |
| 69 | 17.1 | 1.4.3.1 Ejecución de pruebas de integración con componentes | 3d | 2024-10-02 | 2024-10-04 | 28, 34, 40, 46, 52, 58 |  |  | 2024-10-02 | 2024-10-04 | 3d | 2024-10-02 | 2024-10-04 | 30d | 12d | start no earlier than 2024-10-02 | Analista QA; Computador desallo [0.06 unidad]; Servicio pasarelas de pago [0.03 licencia]; Base de datos [0.01 licencia] | 24h |  | 830,000 | 830,000 |  | 830000 | 830000 |
| 70 | 17.2 | 1.4.3.2 Pruebas de interoperabilidad y funcionalidad del sistema | 3d | 2024-10-07 | 2024-10-14 | 28, 34, 40, 46, 52, 58 |  |  | 2024-10-07 | 2024-10-14 | 3d | 2024-10-07 | 2024-10-14 | 23d | 0d | start no earlier than 2024-10-07 | Analista QA; Computador desallo [0.06 unidad]; Servicio pasarelas de pago [0.03 licencia]; Base de datos [0.01 licencia] | 24h |  | 830,000 | 830,000 |  | 830000 | 830000 |
| 71 | 17.3 | 1.4.3.3 Documentación de las pruebas y corrección de fallas | 5d | 2024-10-14 | 2024-10-22 | 28, 34, 40, 46, 52, 58, 27, 70 |  |  | 2024-10-14 | 2024-10-22 | 5d | 2024-10-14 | 2024-10-22 | 23d |  | finish no earlier than 2024-10-22 | Analista QA; Computador desallo [0.06 unidad]; Servicio pasarelas de pago [0.03 licencia]; Base de datos [0.01 licencia] | 40h |  | 1,118,000 | 1,118,000 |  | 1118000 | 1118000 |
| 72 | 18 | **Pruebas de aceptación** | 9d | 2024-10-23 | 2024-11-04 |  |  |  | 2024-10-23 | 2024-11-04 | 9d | 2024-10-23 | 2024-11-04 | 14d |  |  |  | 72h |  | 2,092,000 | 2,092,000 |  |  |  |
| 73 | 18.1 | 1.4.4.1 Pruebas de acuerdo a los casos de uso | 4d | 2024-10-23 | 2024-10-29 | 69 |  |  | 2024-10-23 | 2024-10-29 | 4d | 2024-10-23 | 2024-10-29 | 18d |  | finish no earlier than 2024-10-29 | Analista QA; Computador desallo [0.06 unidad]; Servicio pasarelas de pago [0.03 licencia]; Base de datos [0.01 licencia] | 32h |  | 974,000 | 974,000 |  | 974000 | 974000 |
| 74 | 18.2 | 1.4.4.2 Pruebas con cliente | 5d | 2024-10-29 | 2024-11-04 | 66 |  |  | 2024-10-29 | 2024-11-04 | 5d | 2024-10-29 | 2024-11-04 | 14d |  | finish no earlier than 2024-11-04 | Analista QA; Computador desallo [0.06 unidad]; Servicio pasarelas de pago [0.03 licencia]; Base de datos [0.01 licencia] | 40h |  | 1,118,000 | 1,118,000 |  | 1118000 | 1118000 |
| 75 | 19 | **Capacitación** | 9d | 2024-09-10 | 2024-09-20 |  |  |  | 2024-09-10 | 2024-09-20 | 9d | 2024-09-10 | 2024-09-20 | 21d |  |  |  | 72h |  | 2,546,000 | 2,546,000 |  |  |  |
| 76 | 19.1 | 1.4.5.1 Realizar material de capacitación | 4d | 2024-09-10 | 2024-09-13 | 29, 35, 41, 47, 53, 59 |  |  | 2024-09-10 | 2024-09-13 | 4d | 2024-09-10 | 2024-09-13 | 21d | 0d |  | Profesional en gestión del cambio; Computador admin [0.25 unidad] | 32h |  | 1,201,000 | 1,201,000 |  | 1201000 | 1201000 |
| 77 | 19.2 | 1.4.5.2 Realizar proceso de capacitación con cliente y usuario final | 5d | 2024-09-16 | 2024-09-20 | 76 |  |  | 2024-09-16 | 2024-09-20 | 5d | 2024-09-16 | 2024-09-20 | 21d | 0d |  | Profesional en gestión del cambio; Computador admin [0.25 unidad] | 40h |  | 1,345,000 | 1,345,000 |  | 1345000 | 1345000 |

| ID | WBS | Task | Type | Duration | Start | Finish | Predecessors | Complete | Baseline start | Baseline finish | Baseline duration | Baseline 1 start | Baseline 1 finish | Total slack | Free slack | Resources | Work | Actual work | Cost | Baseline cost | Actual cost | COSTO DE LINEA BASE | BAC |
| --- | --- | --- | --- | --- | --- | --- | --- | --- | --- | --- | --- | --- | --- | --- | --- | --- | --- | --- | --- | --- | --- | --- | --- |
| 78 | 20 | **Documentación y pruebas** |  | 9d | 2024-09-23 | 2024-10-03 |  |  | 2024-09-23 | 2024-10-03 | 9d | 2024-09-23 | 2024-10-03 | 21d |  |  | 56h |  | 2,677,000 | 2,677,000 |  |  |  |
| 79 | 20.1 | 1.4.6.1 Desarrollar manual técnico y de usuario |  | 5d | 2024-09-23 | 2024-09-27 | 77 |  | 2024-09-23 | 2024-09-27 | 5d | 2024-09-23 | 2024-09-27 | 21d | 0d | Profesional en gestión del cambio; Computador admin [0.25 unidad] | 40h |  | 1,345,000 | 1,345,000 |  | 1345000 | 1345000 |
| 80 | 20.2 | 1.4.6.2 Realizar la documentación de las pruebas de rendimiento y seguridad |  | 2d | 2024-09-27 | 2024-10-03 | 79 |  | 2024-09-27 | 2024-10-03 | 2d | 2024-09-27 | 2024-10-03 | 21d |  | Ingeniero de infraestructura; Computador desallo [0.2 unidad]; Base de datos [0.01 licencia] | 16h |  | 1,332,000 | 1,332,000 |  | 1332000 | 1332000 |
| 81 | 21 | **Capacitación técnica y funcional** |  | 2d | 2024-04-10 A | 2024-04-11 A |  | 100% | 2024-04-10 | 2024-04-11 | 2d | 2024-04-10 | 2024-04-11 |  |  |  | 16h | 16h | 913,000 | 913,000 | 913,000 |  |  |
| 82 | 21.1 | 1.5.1.1 Realizar proceso de capacitación personal de soporte y mantenimiento |  | 2d | 2024-04-10 A | 2024-04-11 A |  | 100% | 2024-04-10 | 2024-04-11 | 2d | 2024-04-10 | 2024-04-11 |  |  | Profesional en gestión del cambio; Computador admin [0.25 unidad] | 16h | 16h | 913,000 | 913,000 | 913,000 |  |  |
| 83 | 22 | **Implementación en producción** |  | 5d | 2024-11-04 | 2024-11-08 |  |  | 2024-10-03 | 2024-10-10 | 5d | 2024-10-03 | 2024-10-10 |  |  |  | 8h |  | 1,028,000 | 1,028,000 |  |  |  |
| 84 | 22.1 | 1.5.2.1 Coordinar y realizar el paso a producción |  | 1d | 2024-11-04 | 2024-11-08 | 80 |  | 2024-10-03 | 2024-10-10 | 1d | 2024-10-03 | 2024-10-10 | 0d |  | Gerente de proyectos; Computador admin [0.2 unidad]; Servicio pasarelas de pago [0.03 licencia]; Base de datos [0.01 licencia] | 8h |  | 1,028,000 | 1,028,000 |  | 1028000 | 1028000 |
| 85 | 23 | **Estabilización** |  | 5d | 2024-11-08 | 2024-11-15 |  |  | 2024-10-10 | 2024-10-17 | 5d | 2024-10-10 | 2024-10-17 | 5d |  |  | 56h |  | 3,085,000 | 3,085,000 |  |  |  |
| 86 | 23.1 | 1.5.2.2 Realizar monitoreo continuo del sistema |  | 5d | 2024-11-08 | 2024-11-15 | 84 |  | 2024-10-10 | 2024-10-17 | 5d | 2024-10-10 | 2024-10-17 | 5d |  | Coordinador de proyecto; Computador admin [0.17 unidad]; Servicio pasarelas de pago [0.03 licencia]; Base de datos [0.01 licencia] | 40h |  | 1,753,000 | 1,753,000 |  | 1753000 | 1753000 |
| 87 | 23.2 | 1.5.2.3 Implementar procedimiento de respaldo de información |  | 2d | 2024-11-08 | 2024-11-14 | 84 |  | 2024-10-10 | 2024-10-16 | 2d | 2024-10-10 | 2024-10-16 | 6d |  | Ingeniero de infraestructura; Computador desallo [0.2 unidad]; Base de datos [0.01 licencia] | 16h |  | 1,332,000 | 1,332,000 |  | 1332000 | 1332000 |
| 88 | 24 | **Elaboración de entregables y cierre** |  | 10d | 2024-11-08 | 2024-11-22 |  |  | 2024-10-10 | 2024-10-24 | 10d | 2024-10-10 | 2024-10-24 | 0d |  |  | 16h |  | 1,428,000 | 1,428,000 |  |  |  |
| 89 | 24.1 | 1.5.2.4 Realizar la entrega de documentación, software implementado y material de capacitación |  | 2d | 2024-11-08 | 2024-11-22 | 84 |  | 2024-10-10 | 2024-10-24 | 2d | 2024-10-10 | 2024-10-24 | 0d |  | Gerente de proyectos; Computador admin [0.2 unidad]; Servicio pasarelas de pago [0.03 licencia]; Base de datos [0.01 licencia] | 16h |  | 1,428,000 | 1,428,000 |  | 1428000 | 1428000 |
| 90 | 25 | Reserva de la contingencia | milestone | 0d | 2024-11-22 A | 2024-11-22 A |  | 100% | 2024-04-10 | 2024-04-10 | 0d | 2024-04-10 | 2024-04-10 |  |  |  |  |  | 9,000,000 | 9,000,000 | 9,000,000 | 9000000 | 9000000 |
